# 3GPP_Release-2000

Schedule from MS Project, 2000-01-03 to 2009-03-30, A marks actual dates.

## Calendars

- Standard: Mon-Fri 08:00-12:00, 13:00-17:00; Sat-Sun off.

## Resources

| Resource |
| --- |
| NP |
| N1 |
| N2 |
| N3 |
| N4 |
| N5 |
| TP |
| T1 |
| T2 |
| T3 |
| RP |
| R1 |
| R2 |
| R3 |
| R4 |
| SP |
| S1 |
| S2 |
| S3 |
| S4 |
| S5 |
| PCG |
| GP |
| No |
| CN4 |
| ? |
| WG G2 |
| G2 |
| G1 |
| G4 |
| G3 |
| All |
| Generic |
| MLST |
| G5 |
| S3; G2 |
| WG T2 |
| GP;G1 |
| G4;G5 |
| OMA |
| GP-G2 |
| Yes |
| GP; |
| N4; |
| GP; N1 |
| CT5 |
| C5 |
| C1 |
| C4 |
| C3 |
| C6 |
| G1; |
| 4 |
| ct |
| c;s;r |
| CT;RAN;SA |
| G2, |
| G1; G3 |
| CT6 |
| CT1 |
| CT1, CT3, CT4 |
| C1, C3, C4 |
| CP |

## Schedule

| ID | WBS | Task | Duration | Start | Finish | Complete | Remaining | Baseline start | Baseline finish | Baseline duration | Total slack | Constraint | Resources | Work | Actual work | Text9 | Text6 | Text1 | Text4 | Text8 | Text3 | Text5 |
| --- | --- | --- | --- | --- | --- | --- | --- | --- | --- | --- | --- | --- | --- | --- | --- | --- | --- | --- | --- | --- | --- | --- |
| 1 | 1 | VERSION 2007 June 13th | 1d | 2000-01-03 | 2000-01-03 |  |  | 2000-01-03 | 2000-01-03 | 1d | 2410d |  |  |  |  | 2044 |  |  |  |  |  |  |
| 2 | 2 | "CTRL + a" to display all the 3GPP fields | 1d | 2000-01-03 | 2000-01-03 |  |  | 2000-01-03 | 2000-01-03 | 1d | 2335d |  |  |  |  | 1462 |  |  |  |  |  |  |
| 3 | 3 | Content of Rel-8 (not frozen) | 1d | 2000-01-03 | 2000-01-03 |  |  | 2000-01-03 | 2000-01-03 | 1d | 2335d |  |  |  |  | 2058 |  |  |  |  |  |  |
| 5 | 4 | Release 8 Features | 1d? | 2000-01-03 | 2000-01-03 |  |  | 2000-01-03 | 2000-01-03 | 1d? | 2335d |  | CT;RAN;SA | 8h |  |  | Rel-8 |  |  |  |  |  |
| 6 | 5 | **3G Long Term Evolution** | 320d? | 2006-09-25 A | 2007-12-14 | 21% | 251.28d? | 2006-09-25 | 2007-12-14 | 320d? | 336d |  | RP | 11240h | 2229.6h |  | Rel-8 | LTE | Takehiro Nakamura (NTT DoCoMo) | MCC_RAN |  |  |
| 7 | 5.1 | 3G Long Term Evolution – Physical Layer | 255d? | 2006-09-25 A | 2007-09-14 | 50% | 127.5d? | 2006-09-25 | 2007-09-14 | 255d? | 326d | finish no earlier than 2007-09-14 | R1 | 2040h | 1020h |  | Rel-8 | LTE-Phys | Sadayuki Abeta, NTT DoCoMo | MCC_RAN | 36.2xy |  |
| 8 | 5.2 | 3G Long Term Evolution – Radio Interface Layer 2 and 3 Protocol Aspect | 255d? | 2006-09-25 A | 2007-09-14 | 5% | 242.25d? | 2006-09-25 | 2007-09-14 | 255d? | 326d | finish no earlier than 2007-09-14 | R2 | 2040h | 102h |  | Rel-8 | LTE-L23 | Benoist Sebire, Nokia | MCC_RAN | 36.3xy |  |
| 9 | 5.3 | 3G Long Term Evolution – eUTRAN Interfaces | 255d? | 2006-09-25 A | 2007-09-14 | 5% | 242.25d? | 2006-09-25 | 2007-09-14 | 255d? | 326d | finish no earlier than 2007-09-14 | R3 | 2040h | 102h |  | Rel-8 | LTE-interfaces | Mattias Wahlqvist, Ericsson | MCC_RAN | 36.4xy |  |
| 10 | 5.4 | 3G Long Term Evolution – RF Radio Transmission/Reception, System Performance Requirements and Conformance Testing | 320d? | 2006-09-25 A | 2007-12-14 | 25% | 240d? | 2006-09-25 | 2007-12-14 | 320d? | 261d | finish no earlier than 2007-12-14 | R4 | 2560h | 640h |  | Rel-8 | LTE-RF | Frank Lamprecht, Siemens | MCC_RAN | 36.1xy |  |
| 11 | 6 | **3GPP System Architecture Evolution Specification** | 462d? | 2006-06-08 A | 2008-03-14 | 11% | 409.63d? | 2006-06-08 | 2007-09-14 | 332d? | 271d |  | S2 | 91112h | 9993.79h |  | Rel-8 | SAES | Osok Song (Samsung) | Maurice | 23.228, 23.279 | osok.song@samsung.com |
| 12 | 6.1 | Requirements for evolution of the 3GPP system architecture | 157d? | 2006-06-08 A | 2007-01-12 | 95% | 7.85d? | 2006-06-08 | 2007-01-12 | 157d? | 501d | finish no earlier than 2007-01-12 | S1 | 1256h | 1193.2h |  | Rel-8 | AIPN-SAE | Michael Kurz (T-Mobile International) | Michael | 22.278 | michael.kurz@t-mobile.at |
| 13 | 6.2 | **SA aspects of System Architecture Evolution** | 240d? | 2007-01-02 A | 2007-12-03 | 32% | 164.24d? |  |  |  | 345d |  | S2 | 21352h | 6044h |  | Rel-8 | SAES-SA |  |  |  |  |
| 14 | 6.2.1 | High level functions (common high level functions for all accesses) | 179d? | 2007-01-02 A | 2007-09-07 | 60% | 71.6d? |  |  |  | 406d | finish no earlier than 2007-09-07 | S2 | 1432h | 859.2h |  | Rel-8 | SAES-SA-HLF |  |  |  |  |
| 15 | 6.2.2 | **Functions and procedures for SAE to support LTE access** | 240d? | 2007-01-02 A | 2007-12-03 | 38% | 147.72d? |  |  |  | 345d |  | S2 | 5272h | 1933.2h |  | Rel-8 | SAES-SA-FP_LTE |  |  |  |  |
| 16 | 7.2.2.1 | SAES-SA-FP_LTE with GTP variant | 179d? | 2007-01-02 A | 2007-09-07 | 45% | 98.45d? |  |  |  | 406d | start no earlier than 2007-01-02 | S2 | 1432h | 644.4h |  | Rel-8 | SAES-SA-FP_LTE-GTP |  |  |  |  |
| 17 | 7.2.2.2 | SAES-SA-FP_LTE with IETF variant | 240d? | 2007-01-02 A | 2007-12-03 | 34% | 159.45d? |  |  |  | 345d | finish no earlier than 2007-12-01 | S2 | 1920h | 644.4h |  | Rel-8 | SAES-SA-FP_LTE-IETF |  |  |  |  |
| 18 | 6.2.3 | Functions and procedures for SAE to support 3GPP accesses (LTE <-> 2G/3G) | 179d? | 2007-01-02 A | 2007-09-07 | 45% | 98.45d? |  |  |  | 406d | finish no earlier than 2007-09-07 | S2 | 1432h | 644.4h |  | Rel-8 | SAES-SA-FP_3GPP |  |  |  |  |
| 19 | 6.2.4 | **Functions and procedures for SAE to support non-3GPP accesses** | 240d? | 2007-01-02 A | 2007-12-03 | 35% | 156d? |  |  |  | 345d |  | S2 | 5272h | 1651.2h |  | Rel-8 | SAES-SA-FP_n3GPP |  |  |  |  |
| 20 | 7.2.4.1 | SAES-SA-FP_n3GPP Host-based Mobility aspects | 179d? | 2007-01-02 A | 2007-09-07 | 35% | 116.35d? |  |  |  | 406d | finish no earlier than 2007-09-07 | S2 | 1432h | 501.2h |  | Rel-8 | SAES-SA-FP_n3GPP-HBMob |  |  |  |  |
| 21 | 7.2.4.2 | SAES-SA-FP_n3GPP Network-based Mobility aspects | 240d? | 2007-01-02 A | 2007-12-03 | 35% | 156d? |  |  |  | 345d | finish no earlier than 2007-12-01 | S2 | 1920h | 672h |  | Rel-8 | SAES-SA-FP_n3GPP-NBMob |  |  |  |  |
| 22 | 6.2.5 | Functions and procedures for SAE to support LTE MBMS | 115d? | 2007-06-25 | 2007-11-30 |  |  |  |  |  | 346d | start no earlier than 2007-06-25 | S2 | 920h |  |  | Rel-8 | SAES-SA-FP_LTEMBMS |  |  |  |  |
| 23 | 6.2.6 | Functions and procedures for SAE to support LCS | 80d? | 2007-08-13 | 2007-11-30 |  |  |  |  |  | 346d | start no earlier than 2007-08-13 | S2 | 640h |  |  | Rel-8 | SAES-SA-FP_LCS |  |  |  |  |
| 24 | 6.2.7 | Single Radio Voice Call Continuity | 239d? | 2007-01-02 A | 2007-12-01 | 20% | 191.2d? |  |  |  | 346d | finish no earlier than 2007-12-01 | S2 | 1912h | 382.4h |  | Rel-8 | SAES-SA-SR_VCC |  |  |  |  |
| 25 | 6.2.8 | SAE impacts on IMS | 239d? | 2007-01-02 A | 2007-12-01 | 30% | 167.3d? |  |  |  | 346d | finish no earlier than 2007-12-01 | S2 | 1912h | 573.6h |  | Rel-8 | SAES-SA-on_IMS |  |  |  |  |
| 26 | 6.2.9 | SAE aspects of Emergency Calls | 80d? | 2007-08-13 | 2007-11-30 |  |  |  |  |  | 346d | start no earlier than 2007-08-13 | S2 | 640h |  |  | Rel-8 | SAES-SA-EmCall |  |  |  |  |

Notes:
- 11: S2#52: Specification phase created. New WID approved SA#32
- 12: Moved to SA2 at SA#32
- 13: S2 internal target is September 2007
- 23: SA2 need RAN outputs (RAN dependencies)

| ID | WBS | Task | Duration | Start | Finish | Complete | Remaining | Baseline start | Baseline finish | Baseline duration | Total slack | Constraint | Resources | Work | Actual work | Text1 | Text4 | Text5 | Text6 | Text8 | Text12 |
| --- | --- | --- | --- | --- | --- | --- | --- | --- | --- | --- | --- | --- | --- | --- | --- | --- | --- | --- | --- | --- | --- |
| 27 | 6.3 | **CT aspects of System Architecture Evolution** | 290d? | 2007-02-05 A | 2008-03-14 | 3% | 281.13d? | 2007-02-05 | 2008-03-14 | 290d? | 271d |  | CP | 59320h | 1780.06h | SAES-St3 | Hannu Hietalahti, Nokia | hannu.hietalahti@nokia.com | Rel-8 | Andrijana, Seung Don, Kimmo |  |
| 28 | 6.3.1 | **CT1 aspects of SAES** | 290d? | 2007-02-05 A | 2008-03-14 | 3% | 282.27d? | 2007-02-05 | 2008-03-14 | 290d? | 271d |  | C1 | 16240h | 433.07h | SAES-St3 |  |  | Rel-8 |  |  |
| 29 | 6.3.1.1 | Network selection procedures | 290d? | 2007-02-05 | 2008-03-14 |  |  | 2007-02-05 | 2008-03-14 | 290d? | 271d | start no earlier than 2007-02-05 | C1 | 2320h |  | SAES-St3-netsel |  |  | Rel-8 |  |  |
| 30 | 6.3.1.2 | UE NAS mobility procedures in idle and active mode | 290d? | 2007-02-05 A | 2008-03-14 | 4% | 278.4d? | 2007-02-05 | 2008-03-14 | 290d? | 271d | start no earlier than 2007-02-05 | C1 | 2320h | 92.8h | SAES-St3-NASmob |  |  | Rel-8 |  |  |
| 31 | 6.3.1.3 | Bearer control and QoS aspects | 290d? | 2007-02-05 A | 2008-03-14 | 4% | 278.4d? | 2007-02-05 | 2008-03-14 | 290d? | 271d | start no earlier than 2007-02-05 | C1 | 2320h | 92.8h | SAES-St3-BCQOS |  |  | Rel-8 |  |  |
| 32 | 6.3.1.4 | CT1 SAE impact on existing capabilities | 290d? | 2007-02-05 | 2008-03-14 |  |  | 2007-02-05 | 2008-03-14 | 290d? | 271d | start no earlier than 2007-02-05 | C1 | 2320h |  | SAES-St3-CT1imp |  |  | Rel-8 |  |  |
| 33 | 6.3.1.5 | Interoperability | 290d? | 2007-02-05 A | 2008-03-14 | 4% | 278.4d? | 2007-02-05 | 2008-03-14 | 290d? | 271d | start no earlier than 2007-02-05 | C1 | 2320h | 92.8h | SAES-St3-interop |  |  | Rel-8 |  |  |
| 34 | 6.3.1.6 | CT1 security aspects | 290d? | 2007-02-05 A | 2008-03-14 | 4% | 278.4d? | 2007-02-05 | 2008-03-14 | 290d? | 271d | start no earlier than 2007-02-05 | C1 | 2320h | 92.8h | SAES-St3-CT1sec |  |  | Rel-8 |  |  |
| 35 | 6.3.2 | **CT3 aspects of SAES** | 290d? | 2007-02-05 | 2008-03-14 |  |  | 2007-02-05 | 2008-03-14 | 290d? | 271d |  | C3 | 11600h |  | SAES-St3 |  |  | Rel-8 |  |  |
| 36 | 6.3.2.1 | PCC aspects of SAE | 290d? | 2007-02-05 | 2008-03-14 |  |  | 2007-02-05 | 2008-03-14 | 290d? | 271d | start no earlier than 2007-02-05 | C3 | 2320h |  | SAES-St3-PCC |  |  | Rel-8 |  |  |
| 37 | 6.3.2.2 | Interworking between EPC and external PDNs | 290d? | 2007-02-05 | 2008-03-14 |  |  | 2007-02-05 | 2008-03-14 | 290d? | 271d | start no earlier than 2007-02-05 | C3 | 2320h |  | SAES-St3-intwk |  |  | Rel-8 |  |  |
| 38 | 6.3.2.3 | QoS mechanisms | 290d? | 2007-02-05 | 2008-03-14 |  |  | 2007-02-05 | 2008-03-14 | 290d? | 271d | start no earlier than 2007-02-05 | C3 | 2320h |  | SAES-St3-QoS |  |  | Rel-8 |  |  |
| 39 | 6.3.2.4 | CT3 SAE impact on existing capabilities | 290d? | 2007-02-05 | 2008-03-14 |  |  | 2007-02-05 | 2008-03-14 | 290d? | 271d | start no earlier than 2007-02-05 | C3 | 2320h |  | SAES-St3-CT3imp |  |  | Rel-8 |  |  |
| 40 | 6.3.3 | **CT4 aspects of SAES** | 290d? | 2007-02-05 A | 2008-03-14 | 5% | 275.5d? | 2007-02-05 | 2007-09-21 | 165d? | 271d |  | C4 | 25520h | 1276h | SAES-St3 |  |  | Rel-8 |  |  |
| 41 | 6.3.3.1 | EPC - HSS interface | 290d? | 2007-02-05 A | 2008-03-14 | 5% | 275.5d? | 2007-02-05 | 2007-09-21 | 165d? | 271d | finish no earlier than 2008-03-14 | C4 | 2320h | 116h | SAES-St3-EPC_HSS |  |  | Rel-8 |  |  |
| 42 | 6.3.3.2 | Within EPC | 290d? | 2007-02-05 A | 2008-03-14 | 5% | 275.5d? | 2007-02-05 | 2007-09-21 | 165d? | 271d | finish no earlier than 2008-03-14 | C4 | 2320h | 116h | SAES-St3-EPC |  |  | Rel-8 |  |  |
| 43 | 6.3.3.3 | EPC - GPRS | 290d? | 2007-02-05 A | 2008-03-14 | 5% | 275.5d? | 2007-02-05 | 2007-09-21 | 165d? | 271d | finish no earlier than 2008-03-14 | C4 | 2320h | 116h | SAES-St3-EPC_GPRS |  |  | Rel-8 |  |  |
| 44 | 6.3.3.4 | EPC - non-3GPP IP access | 290d? | 2007-02-05 A | 2008-03-14 | 5% | 275.5d? | 2007-02-05 | 2007-09-21 | 165d? | 271d | finish no earlier than 2008-03-14 | C4 | 2320h | 116h | SAES-St3-EPC_n3G |  |  | Rel-8 |  |  |
| 45 | 6.3.3.5 | AAA/HSS related | 290d? | 2007-02-05 A | 2008-03-14 | 5% | 275.5d? | 2007-02-05 | 2007-09-21 | 165d? | 271d | finish no earlier than 2008-03-14 | C4 | 2320h | 116h | SAES-St3-AAA_HSS |  |  | Rel-8 |  |  |
| 46 | 6.3.3.6 | EPC - AAA interface | 290d? | 2007-02-05 A | 2008-03-14 | 5% | 275.5d? | 2007-02-05 | 2007-09-21 | 165d? | 271d | finish no earlier than 2008-03-14 | C4 | 2320h | 116h | SAES-St3-EPC_AAA |  |  | Rel-8 |  |  |
| 47 | 6.3.3.7 | EPC - EPC | 290d? | 2007-02-05 A | 2008-03-14 | 5% | 275.5d? | 2007-02-05 | 2007-09-21 | 165d? | 271d | finish no earlier than 2008-03-14 | C4 | 2320h | 116h | SAES-St3-EPC_EPC |  |  | Rel-8 |  |  |
| 48 | 6.3.3.8 | SAE / LTE identities | 290d? | 2007-02-05 A | 2008-03-14 | 5% | 275.5d? | 2007-02-05 | 2007-09-21 | 165d? | 271d | finish no earlier than 2008-03-14 | C4 | 2320h | 116h | SAES-St3-IDs |  |  | Rel-8 |  |  |
| 49 | 6.3.3.9 | MME - SGSN "signalling free" protocol | 290d? | 2007-02-05 A | 2008-03-14 | 5% | 275.5d? | 2007-02-05 | 2007-09-21 | 165d? | 271d | finish no earlier than 2008-03-14 | C4 | 2320h | 116h | SAES-St3-MME_SGSN |  |  | Rel-8 |  |  |
| 50 | 6.3.3.10 | CT4 SAE impact on existing capabilities | 290d? | 2007-02-05 A | 2008-03-14 | 5% | 275.5d? | 2007-02-05 | 2007-09-21 | 165d? | 271d | finish no earlier than 2008-03-14 | C4 | 2320h | 116h | SAES-St3-impacts |  |  | Rel-8 |  |  |
| 51 | 6.3.4 | Deleted - UE to EPC NAS signalling (incl. MBMS and QoS aspects) | 290d? | 2007-02-05 | 2008-03-14 |  |  | 2007-02-05 | 2008-03-14 | 290d? | 271d | start no earlier than 2007-02-05 | C1 | 2320h |  | SAES-St3-sig |  |  | Rel-8 |  |  |
| 52 | 6.3.5 | Deleted -User and Control plane protocols | 165d? | 2007-02-05 | 2007-09-21 |  |  | 2007-02-05 | 2007-09-21 | 165d? | 396d | finish no earlier than 2007-09-21 | C4 | 1320h |  | SAES-St3-prot |  |  | Rel-8 |  |  |
| 53 | 6.4 | Deleted - GPRS enhancements for LTE access | 198d? | 2006-12-01 A | 2007-09-04 | 15% | 168.3d? | 2006-12-01 | 2007-09-04 | 198d? | 409d | start no earlier than 2006-12-01 | S2 | 1584h | 237.6h | SAES-GPRS_LTE | Chris Pudney (Vodafone) | chris.pudney@vodafone.com | Rel-8 | Maurice |  |
| 54 | 6.5 | Deleted - Architecture enhancements for non-3GPP accesses | 198d? | 2006-12-01 A | 2007-09-04 | 15% | 168.3d? | 2006-12-01 | 2007-09-04 | 198d? | 409d | start no earlier than 2006-12-01 | S2 | 1584h | 237.6h | SAES-non_3GPP | Irfan Ali (Motorola) | Irfan.Ali@motorola.com | Rel-8 | Maurice |  |
| 55 | 6.6 | Deleted: Stage 2 of architecture for the 3GPP System Architecture Evolution | 290d? | 2007-02-05 A | 2008-03-14 | 4% | 279.7d? | 2006-12-01 | 2007-09-14 | 206d? | 271d |  | S2 | 2320h | 82.4h | SAES-St2 | Chris Pudney (Vodafone) | chris.pudney@vodafone.com | Rel-8 | Maurice | SP-34 |
| 56 | 7 | GERAN support for GERAN - 3G Long Term Evolution interworking | 376d? | 2006-09-08 A | 2008-02-15 | 20% | 300.8d? | 2006-09-08 | 2008-02-15 | 376d? | 291d | finish no earlier than 2008-02-15 | GP | 3008h | 601.6h | GELTE | Han van Bussel, T-Mobile | han.van.bussel@t-mobile.de | Rel-8 | Paolo |  |

Notes:
- 27: CT wide WID approved ib CT#34 / Text3: 24.8yz, 29.8ab, 29.8cd
- 37: 08/03/2007 08:00
- 38: 08/03/2007 08:00
- 39: 08/03/2007 08:00
- 53: SP-34: GPRS enhancements for LTE access item created. / Text3: 23.401
- 54: SP-34: Architecture enhancements for non-3GPP accesses item created. / Text3: 23.402
- 55: THIS LINE IS DELETED, replaced by the 2 Architecture parallel tracks. / Text3: 23.002, 23.060, 23.107, 23.203, 23.228, 23.234, 23.246, 23.271, 23.279
- 56: Text3: 24.008, 43.055, 43.129, 43.246, 44.018, 44.060, 45.002, 45.008, 45.010, 48.008,48.018, 51.010

| ID | WBS | Task | Type | Duration | Start | Finish | Complete | Remaining | Baseline start | Baseline finish | Baseline duration | Total slack | Constraint | Resources | Work | Actual work | Text1 | Text4 | Text6 | Text3 | Text5 | Text8 | Text7 |
| --- | --- | --- | --- | --- | --- | --- | --- | --- | --- | --- | --- | --- | --- | --- | --- | --- | --- | --- | --- | --- | --- | --- | --- |
| 57 | 8 | **Contact Manager for 3GPP UICC applications** |  | 447d? | 2006-06-22 A | 2008-03-07 | 2% | 436.3d? | 2006-06-22 | 2007-06-21 | 261d? | 276d |  | C6 | 6952h | 80.8h | eUPHBOOK | Claus Dietze (Giesecke & Devrient) | Rel-8 |  |  |  |  |
| 58 | 8.1 | Requirements for Contact Manager |  | 202d? | 2006-06-22 A | 2007-03-30 | 5% | 191.9d? | 2006-06-22 | 2006-12-21 | 131d? | 521d | finish no earlier than 2007-03-30 | C6 | 1616h | 80.8h | eUPHBOOK-St1 | Claus Dietze (Giesecke & Devrient) | Rel-8 | 21.111 |  |  |  |
| 59 | 8.2 | Specification of technical solution for the enhanced phonebook |  | 220d? | 2007-05-07 | 2008-03-07 |  |  | 2006-06-22 | 2006-12-21 | 131d? | 276d | finish no earlier than 2008-03-07 | C6 | 1760h |  | eUPHBOOK-Spec | Claus Dietze (Giesecke & Devrient) | Rel-8 | 31.xyz |  |  |  |
| 60 | 8.3 | Deleted - Implementation of eUPHBOOK | milestone | 0d? | 2007-06-21 | 2007-06-21 |  |  | 2006-06-22 | 2007-06-21 | 261d? | 462d | start no earlier than 2007-06-21 | C6 |  |  | eUPHBOOK-St23 |  | Rel-8 | 31.102 |  |  |  |
| 61 | 9 | **Enhancements for VGCS Applications** |  | 438d? | 2006-03-15 A | 2007-11-16 | 45% | 242.98d? | 2006-03-15 | 2007-11-16 | 438d? | 356d |  | S1 | 12176h | 4014.08h | EVA | Amar Deol, Nortel Networks | Rel-8 | 42.068 | deola@nortel.com | Michael |  |
| 62 | 9.1 | SA1 aspects for EVA |  | 191d? | 2006-03-15 A | 2006-12-06 A | 100% |  | 2006-03-15 | 2006-12-06 | 191d? |  | finish no earlier than 2006-12-06 | S1 | 1528h | 1528h | EVA-s1 | Amar Deol, Nortel Networks | Rel-8 | 42.068 | deola@nortel.com | Michael |  |
| 63 | 9.2 | C1 aspects for EVA |  | 271d? | 2006-06-02 A | 2007-06-15 | 50% | 135.5d? | 2006-06-02 | 2007-06-15 | 271d? | 466d | finish no earlier than 2007-06-15 | C1 | 2168h | 1084h | EVA | Milan Patel | Rel-8 | 43.068, 44.068 | milanpa@nortel.com | Andrijana |  |
| 64 | 9.3 | C4 aspects for EVA |  | 261d? | 2006-06-02 A | 2007-06-01 | 46% | 140.94d? | 2006-06-02 | 2007-03-09 | 201d? | 476d | finish no earlier than 2007-06-01 | C4 | 2088h | 960.48h | EVA-c4 |  | Rel-8 | 29.002 |  | Kimmo |  |
| 65 | 9.4 | GERAN2 Aspects of EVA |  | 361d? | 2006-06-30 A | 2007-11-16 | 10% | 324.9d? | 2006-06-30 | 2007-11-16 | 361d? | 356d | finish no earlier than 2007-11-16 | G2 | 2888h | 288.8h | EVA-EVGCSA | Frank Billenkamp (Notrtel Networks) | Rel-8 | 44.018, 48.008 | frank.billenkamp@nortel.com | Gert |  |
| 66 | 10 | **IMS Service Brokering enhancements** |  | 69d? | 2005-12-07 A | 2006-03-13 A | 100% |  | 2005-12-07 | 2006-03-13 | 69d? |  |  | S1 | 1104h | 1104h | ISB | John-Luc Bakker (Telcordia) | Rel-8 | 22.228 | jbakker@telcordia.com | Michael |  |
| 67 | 10.1 | Stage 1 of ISB |  | 69d? | 2005-12-07 A | 2006-03-13 A | 100% |  | 2005-12-07 | 2006-03-13 | 69d? |  | finish no earlier than 2006-03-13 | S1 | 552h | 552h | ISB-s1 | John-Luc Bakker (Telcordia) | Rel-8 | 22.228 | jbakker@telcordia.com | Michael |  |
| 68 | 11 | **Multimedia Priority Service** |  | 337d? | 2006-06-08 A | 2007-09-21 | 65% | 116.75d? | 2006-06-08 | 2007-09-21 | 337d? | 396d |  | S1 | 7072h | 4204h | PRIOR | Jim Garrahan (Telcordia) | Rel-8 | 22.153 | jgarraha@telcordia.com | Michael |  |
| 69 | 11.1 | Service Requirements for PRIOR |  | 336d? | 2006-06-08 A | 2007-09-20 | 75% | 84d? | 2006-06-08 | 2007-09-20 | 336d? | 397d | finish no earlier than 2007-09-20 | S1 | 2688h | 2016h | PRIOR-EMR | Jim Garrahan (Telcordia) | Rel-8 | 22.153 | jgarraha@telcordia.com | Michael |  |
| 70 | 11.2 | Multimedia Priority Service for PRIOR - Stage 3 |  | 211d? | 2006-12-01 A | 2007-09-21 | 50% | 105.5d? | 2006-12-01 | 2007-09-21 | 211d? | 396d | finish no earlier than 2007-09-21 | C1 | 1688h | 844h | PRIOR-MM | Keith Drage, Alcatel-Lucent | Rel-8 | 24.229 | drage@Alcatel-Lucent.com | Andrijana |  |
| 71 | 12 | eCall Data Transfer – Requirements |  | 51d? | 2006-09-28 A | 2006-12-07 A | 100% |  | 2006-09-28 | 2006-12-07 | 51d? |  | finish no earlier than 2006-12-07 | S1 | 408h | 408h | EData | Rhys Robinson (Airbiquity) | Rel-8 | 22.101, 22.105 | rrobinson@airbiquity.com | Maurice |  |
| 72 | 13 | Local Charging Zone Requirements |  | 51d? | 2006-09-28 A | 2006-12-07 A | 100% |  | 2006-09-28 | 2006-12-07 | 51d? |  | finish no earlier than 2006-12-07 | S1 | 408h | 408h | LCZR | Hong Liu (China Mobile) | Rel-8 | 22.115 | liuhongyfw@chinamobile.com | Michael |  |
| 73 | 14 | Enhancements to BS30 Bearer service for Videotelephony |  | 51d? | 2007-01-04 A | 2007-03-15 | 10% | 45.9d? | 2007-01-04 | 2007-03-15 | 51d? | 532d | finish no earlier than 2007-03-15 | S1 | 408h | 40.8h | BS30 | Andre Jarvis (3) | Rel-8 | 22.002, 22.004, 22.101, 22.105, 24.008 | andre.jarvis@three.co.uk | Michael |  |
| 74 | 15 | Deleted (never approved) FBI Phase 2 |  | 349d? | 2006-06-30 | 2007-10-31 |  |  | 2006-06-30 | 2007-10-31 | 349d? | 368d | start no earlier than 2006-06-30 | S2 | 2792h |  | FBI2 |  | Rel-8 |  |  | Maurice | TSG |
| 75 | 16 | **System enhancements for TISPAN Rel 2** |  | 338d? | 2006-08-16 A | 2007-11-30 | 16% | 282.75d? | 2006-06-30 | 2007-10-31 | 349d? | 346d |  | S2 | 5584h | 728.75h | FBI2-TISP2 |  | Rel-8 |  |  |  |  |
| 76 | 16.1 | Deleted (never approved) - Stage 2 of FBI for TISPAN R2 - Rel 8 |  | 157d? | 2007-04-26 A | 2007-11-30 | 5% | 149.15d? | 2006-06-30 | 2007-10-31 | 349d? | 346d | start no earlier than 2007-04-26 | S2 | 1256h | 62.8h | FBI2-TISP2-s2 |  | Rel-8 |  |  |  |  |
| 77 | 16.2 | Protocol impact of FBI for TISPAN R2 |  | 152d? | 2006-08-16 | 2007-03-15 |  |  | 2006-08-16 | 2007-03-15 | 152d? | 532d | finish no earlier than 2007-03-15 | C1 | 1216h |  | FBI2-TISP2-c1 |  | Rel-8 |  |  |  |  |
| 78 | 16.3 | Charging harmonization for NGN between 3GPP and ATIS-TMOC |  | 51d? | 2006-09-28 A | 2006-12-07 A | 100% |  | 2006-09-28 | 2006-12-07 | 51d? |  | finish no earlier than 2006-12-07 | S5 | 408h | 408h | FBI2-TISP2-CH | Amdocs | Rel-7 | 32.297 | yishai.brown@amdocs.com | Adrian |  |
| 79 | 17 | **IMS Enhancements for support of Packet Cable access** |  | 272d? | 2006-12-06 A | 2007-12-20 | 35% | 177.67d? |  |  |  | 332d |  | S2 | 18288h | 5482.28h | PktCbl |  | Rel-8 |  |  |  |  |
| 80 | 17.1 | **IMS Enhancements for Security Requirements in Support of Cable Deployments** |  | 272d? | 2006-12-06 A | 2007-12-20 | 22% | 213.47d? | 2006-12-06 | 2007-12-20 | 272d? | 332d |  | S3 | 7232h | 1088h | PktCbl-Sec | Steve Dotson (Cablelabs) | Rel-8 | 33.203, 33.210, 33.220, 24.229 | s.dotson@cablelabs.com | Michael |  |
| 81 | 17.1.1 | S3 Aspects of PktCbl-Sec |  | 272d? | 2006-12-06 A | 2007-12-20 | 50% | 136d? | 2006-12-06 | 2007-12-20 | 272d? | 332d | finish no earlier than 2007-12-20 | S3 | 2176h | 1088h | PktCbl-Sec | Steve Dotson (Cablelabs) | Rel-8 | 33.203, 33.210, 33.220, 24.229 | s.dotson@cablelabs.com | Michael |  |
| 82 | 17.1.2 | CT1 Aspects of PktCbl-Sec |  | 180d? | 2007-03-26 | 2007-11-30 |  |  |  |  |  | 346d | start no earlier than 2007-03-26 | C1 | 1440h |  | PktCbl-Sec | David Hancock (CableLabs) | Rel-8 | 24.229, 24.109 | D.Hancock@ CableLabs.com | Andrijana |  |
| 83 | 17.1.3 | CT4 Aspects of PktCbl-Sec |  | 180d? | 2007-03-26 | 2007-11-30 |  |  |  |  |  | 346d | start no earlier than 2007-03-26 | C4 | 1440h |  | PktCbl-Sec | David Hancock (CableLabs) | Rel-8 | 29.228, 29229, 23.008, | D.Hancock@ CableLabs.com | Kimmo |  |

Notes:
- 57: Moved from Rel-7 to Rel-8 at CT#33. C6-43: WI Name change to Enhanced USIM Phonebook. Completion date updated to 03/2008. Supporting Members: Giesecke & Devrient, T-Mobile, SagemOrga, Oberthur, Gemalto, Telefonica, ST Incard, Microelectronica, Cingular, O
- 58: C6-43: Name Changed to Requirements for Contact Manager. Expected completion updated from CT#34 to CT#35.
- 59: New TS 31.xyz to be produced
- 64: CT4#32: Crs are presented and in principle agreed, waiting for the approval of stage2...
- 68: Created by MCC to group 320023 (Stage 1) and 340012 (Stage 3) wrongly shown as idependent Features
- 69: Official name is "Multimedia Priority Service" but this is identical to UID 31041
- 70: "CT1" corrected into "C1"
- 74: Added by MCC as a consequence of the move to Rel8 of TISPAN Rel-2 impacts on 3GPP
- 76: It might be more appropriate to introduce the individual functions instead of a global title. SA2 WID expected at SA#36
- 78: 09/2006 SA#33 WID approved
- 82: Supporting Companies:
- 83: Supporting Companies:

| ID | WBS | Task | Type | Duration | Start | Finish | Complete | Remaining | Baseline start | Baseline finish | Baseline duration | Total slack | Constraint | Resources | Work | Actual work | Text1 | Text6 | Text4 | Text5 | Text8 | Text7 |
| --- | --- | --- | --- | --- | --- | --- | --- | --- | --- | --- | --- | --- | --- | --- | --- | --- | --- | --- | --- | --- | --- | --- |
| 84 | 17.2 | **IMS Enhancements for Cable Client Types and Deployment Models** |  | 215d? | 2007-02-05 A | 2007-11-30 | 7% | 199.82d? |  |  |  | 346d |  | S2 | 4440h | 394.35h | PktCbl-Deploy | Rel-8 |  |  |  |  |
| 85 | 17.2.1 | Architecture aspects of PktCbl-Deploy |  | 160d? | 2007-02-05 A | 2007-09-14 | 15% | 136d? |  |  |  | 401d | start no earlier than 2007-02-05 | S2 | 1280h | 192h | PktCbl-Deploy | Rel-8 |  |  |  |  |
| 86 | 17.2.2 | CT1 aspects of PktCbl-Deploy |  | 180d? | 2007-03-26 | 2007-11-30 |  |  |  |  |  | 346d | start no earlier than 2007-03-26 | C1 | 1440h |  | PktCbl-Deploy | Rel-8 | David Hancock (CableLabs) | D.Hancock@ CableLabs.com | Andrijana |  |
| 87 | 17.3 | **IMS Inter-working Aspects in Support of Cable Regulatory requirements** |  | 215d? | 2007-02-05 A | 2007-11-30 | 87% | 28.46d? |  |  |  | 346d |  | S2 | 4440h | 3245.29h | PktCbl-Intw | Rel-8 | Bernie McKibben (CableLabs) | B.McKibben@CableLabs.com | Maurice |  |
| 88 | 17.3.1 | Architecture aspects of PktCbl-Interwork |  | 160d? | 2007-02-05 A | 2007-09-14 A | 100% |  |  |  |  |  | start no earlier than 2007-02-05 | S2 | 1280h | 1280h | PktCbl-Intw | Rel-8 | Bernie McKibben (CableLabs) | B.McKibben@CableLabs.com | Maurice |  |
| 89 | 17.3.2 | CT1 aspects of PktCbl-Interwork |  | 180d? | 2007-03-26 A | 2007-11-30 | 75% | 45d? |  |  |  | 346d | start no earlier than 2007-03-26 | C1 | 1440h | 1080h | PktCbl-Intw | Rel-8 | David Hancock (CableLabs) | D.Hancock@ CableLabs.com | Andrijana |  |
| 90 | 18 | Services Alignment and Migration |  | 256d? | 2006-12-06 A | 2007-11-28 | 65% | 89.6d? | 2006-09-28 | 2007-09-20 | 256d? | 348d | finish no earlier than 2007-09-20 | S1 | 2048h | 1331.2h | ServAl | Rel-8 | Feng Lingjuan (China Mobile) | (fenglingjuan@chinamobile.com) | Michael |  |
| 91 | 19 | Support of Customised Alerting Tone Service |  | 207d? | 2006-12-06 A | 2007-09-20 | 65% | 72.45d? | 2006-12-06 | 2007-09-20 | 207d? | 397d | finish no earlier than 2007-09-20 | S1 | 1656h | 1076.4h | CusAlert | Rel-8 | Feng Lingjuan (China Mobile) | (fenglingjuan@chinamobile.com) | Michael |  |
| 92 | 20 | I-WLAN NSP |  | 6d? | 2006-12-06 A | 2006-12-13 | 50% | 3d? | 2006-12-06 | 2006-12-13 | 6d? | 598d | finish no earlier than 2006-12-13 | S1 | 48h | 24h | IWLANNSP | Rel-8 | Chris Friel (O2) | chris.friel@o2.com | Michael |  |
| 93 | 21 | **Support of Service-Level Interworking for Messaging Services** |  | 195d? | 2007-03-26 A | 2007-12-24 | 14% | 168.29d? | 2006-12-06 | 2007-06-07 | 132d? | 330d |  | S1 | 2944h | 1245.6h | MESSIW | Rel-8 | Liu Ling (Huawei) | ling.liu@huawei.com | Michael |  |
| 94 | 21.1 | Stage 1 aspects of Service-Level Interworking for Messaging Services | milestone | 0d? | 2007-03-26 A | 2007-03-26 A | 100% |  | 2006-12-06 | 2007-06-07 | 132d? |  | finish no earlier than 2007-12-01 | S1 |  |  | MESSIW-St1 | Rel-8 | Liu Ling (Huawei) | ling.liu@huawei.com | Michael |  |
| 95 | 21.2 | Stage 2 aspects of Service-Level Interworking for Messaging Services |  | 173d? | 2007-04-26 A | 2007-12-24 | 14% | 149.3d? | 2006-12-06 | 2007-06-07 | 132d? | 330d | finish no earlier than 2007-12-21 | S2 | 1384h | 189.6h | MESSIW-St2 | Rel-8 | Duan Xiaoqin (Huawei) | duanxiaoqin@huawei.com | Maurice |  |
| 96 | 22 | **OAM&P 8 (not yet official)** |  | 857d? | 2005-09-02 A | 2008-12-15 | 18% | 702.19d? |  |  |  | 75d |  | S5 | 29392h | 4388.8h | OAM8 | Rel-8 | Christian Toche | christian.toche@huawei.com | Adrian |  |
| 97 | 22.1 | Integration Reference Point (IRP) Methodology |  | 857d? | 2005-09-02 A | 2008-12-15 | 20% | 685.6d? | 2005-09-02 | 2008-12-15 | 857d? | 75d | finish no earlier than 2008-12-15 | S5 | 6856h | 1371.2h |  | Rel-8 | Ericsson |  | Adrian |  |
| 98 | 22.2 | Advanced Alarming on Itf-N (Study + Implementation) |  | 596d? | 2005-09-02 A | 2007-12-14 | 20% | 476.8d? | 2005-09-02 | 2007-06-14 | 465d? | 336d | finish no earlier than 2007-12-14 | S5 | 4768h | 953.6h |  | Rel-8 | Siemens |  | Adrian |  |
| 99 | 22.3 | CN CS Bearer Transport Network (BTN) relative NRM |  | 596d? | 2005-09-02 A | 2007-12-14 | 20% | 476.8d? | 2005-09-02 | 2007-03-15 | 400d? | 336d | finish no earlier than 2007-12-14 | S5 | 4768h | 953.6h |  | Rel-8 | China Mobile |  | Adrian |  |
| 100 | 22.4 | IP bearer network Performance measurement definitions |  | 596d? | 2005-09-02 A | 2007-12-14 | 20% | 476.8d? | 2005-09-02 | 2007-03-15 | 400d? | 336d | finish no earlier than 2007-12-14 | S5 | 4768h | 953.6h |  | Rel-8 | China Mobile |  | Adrian |  |
| 101 | 22.5 | HSUPA performance measurements |  | 196d? | 2007-06-07 A | 2008-03-06 | 5% | 186.2d? |  |  |  | 277d | finish no earlier than 2008-03-06 | S5 | 1568h | 78.4h |  | Rel-8 | China Mobile |  |  |  |
| 102 | 22.6 | Key Performance Indicator |  | 196d? | 2007-06-07 A | 2008-03-06 | 5% | 186.2d? |  |  |  | 277d | finish no earlier than 2008-03-06 | S5 | 1568h | 78.4h |  | Rel-8 | China Mobile |  |  |  |
| 103 | 23 | Registration in Densely-populated area |  | 4d? | 2007-03-12 A | 2007-03-15 | 90% | 0.4d? |  |  |  | 532d | start no earlier than 2007-03-12 | S1 | 32h | 28.8h | RED | Rel-8 | Tsuyoshi Takakura (NTT DoCoMo Inc.) | takakurat@s1.nttdocomo.co.jp | Michael |  |
| 104 | 24 | Lawful Interception in the 3GPP Rel-8 |  | 265d? | 2007-03-12 A | 2008-03-14 | 20% | 212d? |  |  |  | 271d | finish no earlier than 2008-03-14 | S3 | 2120h | 424h | LI8 | Rel-8 | Berthold Wilhelm (BMWi/BNetzA) | berthold.wilhelm@bnetza.de | Michael |  |
| 105 | 25 | **Rel-8 Improvements of the Radio Interface** |  | 215d? | 2007-03-05 A | 2007-12-28 |  | 215d? | 2004-09-15 | 2007-06-15 | 718d? | 326d |  | RP | 7840h | 808h | RInImp8 | Rel-8 |  |  | Claude |  |
| 106 | 25.1 | UMTS 1500 MHz |  | 140d? | 2007-03-05 | 2007-09-14 |  |  | 2004-09-15 | 2005-06-14 | 195d? | 401d | finish no earlier than 2007-09-14 | R4 | 1120h |  | RInImp8-UMTS1500 | Rel-8 | Takehiro Nakamura | NTT DoCoMo | Claude | TSG |
| 107 | 25.2 | UMTS 700 MHz |  | 215d? | 2007-03-05 | 2007-12-28 |  |  | 2004-09-15 | 2005-06-14 | 195d? | 326d | start no earlier than 2007-03-05 | R4 | 1720h |  | RInImp8-UMTS700 | Rel-8 | Tuomo Saynajakangas | Nokia | Claude | TSG |
| 108 | 25.3 | UMTS 2300 MHz |  | 215d? | 2007-03-05 | 2007-12-28 |  |  | 2004-09-15 | 2005-06-14 | 195d? | 326d | start no earlier than 2007-03-05 | R4 | 1720h |  | RInImp8-UMTS2300 | Rel-8 | Marc Grant | marc.grant@cingular.com | Claude | TSG |
| 109 | 25.4 | Further Improved Performance Requirements for UMTS/HSDPA UE (FDD) |  | 215d? | 2007-03-05 | 2007-12-28 |  |  | 2005-12-15 | 2007-03-15 | 326d? | 326d | finish no earlier than 2007-12-28 | R4 | 1720h |  | RInImp8-2BIC | Rel-8 | Marc Grant, Cingular | marc.grant@cingular.com | MCC_RAN |  |

Notes:
- 86: Supporting Companies: / Text3: 24.229, 24167
- 87: Supporting Companies: CableLabs, Nortel, Cisco, Samsung, Alcatel-Lucent, Siemens, Motorola, Hewlett-Packard, Ericsson / Text3: 23.228
- 88: Supporting Companies: CableLabs, Nortel, Cisco, Samsung, Alcatel-Lucent, Siemens, Motorola, Hewlett-Packard, Ericsson / Text3: 23.228
- 89: Supporting Companies: / Text3: 24.229
- 90: previous names were Services Alignment, Service Migration / Text3: 22.182
- 91: Text3: 22.182
- 92: Text3: 22.234
- 93: Text3: 22.105, 22.340
- 94: Text3: 22.105, 22.340
- 95: WID Updated S2-57 / Text3: TR 23.abc, TS 23.xyz, 22.105, 22.340
- 96: Created to encompass the Rel7 Work Tasks shifted to Rel8
- 97: Request to TSG#35 to move to Release 8 / Text3: 32.155
- 98: Request to TSG#35 to move to Release 8 / Text3: 32.121/2/3/5
- 99: Request to TSG#35 to move to Release 8 / Text3: 32.74x
- 100: Request to TSG#35 to move to Release 8 / Text3: 32.404,32.405,32.406,32.407
- 101: Text3: 32.405
- 102: Text3: 32.405
- 103: One CR at SA #35 / Text3: 22.101
- 104: End date to be determined when Rel-8 frozen. / Text3: 33.106, 33.107, 33.108
- 106: Text3: TS25.101, TS25.104, TS25.133, TS25.141, TS25.331, TS25.942, TS25.306, TS25.307, TS34.121
- 107: Text3: TS25.101, TS25.104, TS25.133, TS25.141, TS25.331, TS25.942, TS25.306, TS25.307, TS34.121
- 108: Text3: TS25.101, TS25.104, TS25.133, TS25.141, TS25.331, TS25.942, TS25.306, TS25.307, TS34.121

| ID | WBS | Task | Duration | Start | Finish | Complete | Remaining | Baseline start | Baseline finish | Baseline duration | Total slack | Constraint | Resources | Work | Actual work | Text1 | Text4 | Text5 | Text6 | Text8 | Text3 | Text7 | Text12 |
| --- | --- | --- | --- | --- | --- | --- | --- | --- | --- | --- | --- | --- | --- | --- | --- | --- | --- | --- | --- | --- | --- | --- | --- |
| 110 | 26 | **Personal Network Management** | 971d? | 2005-07-11 A | 2009-03-30 | 24% | 737.94d? | 2005-07-11 | 2007-10-30 | 601.6d? | 0d |  | S1 | 23492.8h | 5409.51h | PNM | Armin Toepfer, Vodafone | armin.toepfer@vodafone.com | Rel-8 | Mike |  |  |  |
| 111 | 26.1 | Stage 1 of PNM | 276d? | 2005-07-11 A | 2006-07-31 | 85% | 41.4d? | 2005-07-11 | 2006-07-31 | 276d? | 695d | start no earlier than 2005-07-11 | S1 | 2208h | 1876.8h | PNM |  |  | Rel-8 |  | 22.259, 23.818 |  |  |
| 112 | 26.2 | Actual Requirements of PNM | 526d? | 2007-03-26 | 2009-03-30 |  |  |  |  |  | 0d | start no earlier than 2007-03-26 | C1 | 4208h |  | PNM | Yang Lu, |  | Rel-8 |  |  |  |  |
| 113 | 26.3 | Stage 2 of PNM | 526d? | 2007-03-26 A | 2009-03-30 | 40% | 315.6d? |  |  |  | 0d | finish no earlier than 2009-03-30 | C1 | 4208h | 1683.2h | PNM | Yang Lu, |  | Rel-8 |  |  |  |  |
| 114 | 26.4 | **Stage 3 of PNM** | 263d? | 2007-03-26 | 2008-03-26 |  |  | 2005-07-11 | 2006-07-31 | 276d? | 263d |  | C1 | 5163.2h |  | PNM | Yang Lu, |  | Rel-8 |  |  |  |  |
| 115 | 26.4.1 | CT1 aspects of PNM | 263d? | 2007-03-26 | 2008-03-26 |  |  |  |  |  | 263d | start no earlier than 2007-03-26 | C1 | 2104h |  | PNM | Yang Lu, |  | Rel-8 |  | 24.229 |  |  |
| 116 | 26.4.2 | CT4 aspects of PNM | 263d? | 2007-03-26 | 2008-03-26 |  |  |  |  |  | 263d | start no earlier than 2007-03-26 | C4 | 2104h |  | PNM | Yang Lu, |  | Rel-8 |  | 23.008, 23.018, 29.002, 29.328, 29.329 |  |  |
| 117 | 27 | GAN Enhancements | 206d? | 2006-11-17 A | 2007-08-31 | 90% | 20.6d? |  |  |  | 411d | start no earlier than 2006-11-17 | GP | 1648h | 1483.2h | EGAN | Janne Linkola (T-Mobile) | janne.linkola@t-mobile.com | Rel-8 | Paolo | 43.902 |  |  |
| 118 | 28 | **Charging Management small Enhancements** | 420d? | 2006-05-08 A | 2007-12-14 | 10% | 377.5d? | 2006-05-22 | 2007-03-15 | 214d? | 336d |  | S5 | 6648h | 345.47h | CH8 | Orange | alain.bibas@orange-ft.com | Rel-8 | Adrian | 32.2xy |  |  |
| 119 | 28.1 | Online charging correlation | 420d? | 2006-05-08 A | 2007-12-14 | 10% | 378d? | 2006-05-22 | 2007-03-15 | 214d? | 336d | finish no earlier than 2007-12-14 | S5 | 3360h | 336h |  | Orange |  | Rel-8 |  | 32.240, 32.296 |  |  |
| 120 | 28.2 | SMS online charging | 1d? | 2007-04-02 A | 2007-04-02 | 60% | 0.4d? |  |  |  | 520d |  | S5 | 8h | 4.8h |  | Vodafone |  | Rel-8 |  | 32.274, CR 32.240 / 299/ 298 |  |  |
| 121 | 29 | **OSA Rel-8** | 336d? | 2007-08-23 | 2008-12-04 |  |  | 2005-03-15 | 2007-06-09 | 584d? | 82d |  | S1 | 5016h |  | OSA8 | Orange |  | Rel-8 | Michael |  | TSG |  |
| 122 | 29.1 | OSA Stage 1 - Service Requirements | 336d? | 2007-08-23 | 2008-12-04 |  |  | 2005-03-15 | 2005-06-08 | 62d? | 82d | finish no earlier than 2008-12-04 | S1 | 2688h |  | OSA8 |  |  | Rel-8 | Michael | 22.127 | TSG |  |
| 123 | 29.2 | OSA Stage 2/3 enhancements | 291d? | 2007-10-25 | 2008-12-04 |  |  | 2006-04-28 | 2007-06-09 | 291d? | 82d | finish no earlier than 2008-12-04 | C5 | 2328h |  | OSA8 | Orange |  | Rel-8 | Adrian | 23.198, 29.198/9 |  |  |
| 124 | 30 | (Small) Technical Enhancements and Improvements for Rel-8 | 400d? | 2007-01-01 | 2008-07-11 |  |  | 2007-01-01 | 2008-07-11 | 400d? | 186d | start no earlier than 2007-01-01 | All | 3200h |  | TEI8 |  |  | Rel-8 |  |  |  |  |
| 125 | 31 | Delete - was a Rel7 item - LCS for 3GPP Interworking WLAN | 245d? | 2006-10-23 | 2007-09-28 |  |  | 2006-10-23 | 2007-09-28 | 245d? | 391d | finish no earlier than 2007-09-28 | S2 | 1960h |  | LCS4_IWLAN | Donghee Shim (LG Electronics Inc.) | dhshim@lge.com | Rel-8 | Maurice | 23.234, 23.271, 23.167 |  | S2-56 |
| 126 | 32 | Rel-8 Feasibility Studies | 1d? | 2000-01-03 | 2000-01-03 |  |  | 2000-01-03 | 2000-01-03 | 1d? | 2410d |  | CT;RAN;SA | 8h |  |  |  |  | Rel-8 |  |  |  |  |
| 127 | 33 | Study on Facilitating Machine to Machine Communication in GSM and UMTS (M2M) | 161d? | 2005-11-04 A | 2006-06-16 | 90% | 16.1d? | 2005-11-04 | 2006-06-16 | 161d? | 726d | finish no earlier than 2006-06-16 | S1 | 1288h | 1159.2h | M2M | Juergen Merkel, Siemens AG |  | Rel-8 | Michael | 22.868 |  |  |
| 128 | 34 | FS on Network Composition | 211d? | 2005-12-07 A | 2006-09-27 | 90% | 21.1d? | 2005-12-07 | 2006-09-27 | 211d? | 653d | finish no earlier than 2006-09-27 | S1 | 1688h | 1519.2h | NetComp | Joerg Swetina (Siemens) | joerg.swetina@siemens.com | Rel-8 |  | 22.980 |  |  |
| 129 | 35 | Study on Charging Aspects of 3GPP System Evolution | 179d? | 2007-04-02 A | 2007-12-06 | 20% | 143.2d? | 2006-05-10 | 2008-12-15 | 679d? | 342d | finish no earlier than 2007-12-06 | S5 | 1432h | 286.4h | FSSAEcharg | Siemens | gerald.goermer@siemens.com | Rel-8 |  | TR 32.820 |  | SP-32 |
| 130 | 36 | **All-IP Network (AIPN)** | 448d? | 2004-06-28 A | 2006-03-15 A | 100% |  | 2004-06-28 | 2006-03-15 | 448d? |  |  | S1 | 8672h | 8672h | AIPN | Chris Sachno (NTT DoCoMo) | c.masyu@nttdocomo.co.jp | Rel-8 | Michael | 22.978 | TSG |  |
| 131 | 36.1 | All-IP Network Feasibility Study | 188d? | 2004-06-28 A | 2005-03-16 A | 100% |  | 2004-06-28 | 2005-03-16 | 188d? |  | start no earlier than 2004-06-28 | S1 | 1504h | 1504h | AIPFS | Chris Sachno (NTT DoCoMo) | c.masyu@nttdocomo.co.jp | Rel-8 | Michael | 22.978 | TSG |  |
| 132 | 36.2 | Stage1 | 448d? | 2004-06-28 A | 2006-03-15 A | 100% |  | 2004-06-28 | 2006-03-15 | 448d? |  | finish no earlier than 2006-03-15 | S1 | 3584h | 3584h | AIPN | Chris Sachno (NTT DoCoMo) | c.masyu@nttdocomo.co.jp | Rel-8 | Michael | 22.258 | TSG |  |
| 133 | 37 | Study on Stage 2 aspects of IMS Service Brokering | 380d? | 2006-06-19 A | 2007-12-01 | 47% | 201.4d? | 2006-06-19 | 2007-06-22 | 265d? | 346d | finish no earlier than 2007-12-01 | S2 | 3040h | 1428.8h | ISB_ST2_SDY | Raquel Morera (Telcordia); F. Joe Lin (Telcordia) | raquel@research.telcordia.com | Rel-8 | Maurice | 23.810 |  |  |
| 134 | 38 | Study of Requirements of IMS Multimedia Conferencing | 205d? | 2006-06-08 A | 2007-03-21 | 30% | 143.5d? | 2006-06-08 | 2007-03-21 | 205d? | 528d | finish no earlier than 2007-03-21 | S1 | 1640h | 492h | SI-IMSconf | Zheng Jianping (China Mobile ) | zhengjianping@chinamobile.com | Rel-8 | Michael | 22.948 |  |  |
| 135 | 39 | Study on support of a Public Warning System | 205d? | 2006-06-08 A | 2007-03-21 | 55% | 92.25d? | 2006-06-08 | 2007-03-21 | 205d? | 528d | start no earlier than 2006-06-08 | S1 | 1640h | 902h | PWS-SI | Mark Young (T-mobile) | mark.younge@t-mobile.com | Rel-8 | Michael | 22.968 |  |  |
| 136 | 40 | Study on Protection against SMS and MMS spam | 402d? | 2006-06-08 A | 2007-12-21 | 10% | 361.8d? | 2006-06-08 | 2007-03-21 | 205d? | 331d | finish no earlier than 2007-12-21 | S3 | 3216h | 321.6h | CPSMal | Eric Gauthier (Orange SA) | eric.gauthier@orange.ch | Rel-8 | Michael | 33.9xx |  |  |
| 137 | 41 | Study of VCC support for Emergency Calls | 387d? | 2006-06-08 A | 2007-12-01 | 15% | 328.95d? | 2006-06-08 | 2007-03-23 | 207d? | 346d | finish no earlier than 2007-12-01 | S2 | 3096h | 464.4h | FSVCCEm | Bob Beeson, Alcatel-Lucent |  | Rel-8 | Maurice | 23.826 |  |  |
| 138 | 42 | Study on Centralised IMS Service Control | 290d? | 2006-10-23 A | 2007-12-01 | 60% | 116d? | 2006-10-23 | 2007-09-14 | 235d? | 346d | finish no earlier than 2007-12-01 | S2 | 2320h | 1392h | IMS_CSC | Andy Bennett (Alcatel-Lucent) | andybennett@Alcatel-Lucent.com | Rel-8 | Maurice | 23.892 |  |  |
| 139 | 43 | Study on IMS utilizing multicast bearer services | 398d? | 2006-03-22 A | 2007-09-28 | 75% | 99.5d? | 2006-03-22 | 2007-03-02 | 248d? | 391d | finish no earlier than 2007-09-28 | S2 | 3184h | 2388h | FS-MLTICAST-IMS | Fiona Zhu (Siemens AG) |  | Rel-8 | Maurice | 23.847 |  |  |
| 140 | 44 | Study on Paging Permission with Access Control | 256d? | 2006-09-28 A | 2007-09-20 | 60% | 102.4d? | 2006-09-28 | 2007-09-20 | 256d? | 397d | finish no earlier than 2007-09-20 | S1 | 2048h | 1228.8h | PPAC | Katsuhiro Noguchi (NTT DoCoMo Inc.) | noguchi@nttdocomo.co.jp | Rel-8 | Michael | 22.908 |  |  |
| 141 | 45 | Study on Non 3GPP access NSP | 207d? | 2006-12-06 A | 2007-09-20 | 15% | 175.95d? | 2006-12-06 | 2007-09-20 | 207d? | 397d | start no earlier than 2006-12-06 | S1 | 1656h | 248.4h | N3GtoNSP | Chris Friel (O2) | chris.friel@o2.com | Rel-8 | Michael | 22.812 |  |  |
| 142 | 46 | Study on Value Added Services for Short Message Service | 263d? | 2006-12-06 A | 2007-12-07 | 10% | 236.7d? | 2006-12-06 | 2007-12-07 | 263d? | 341d | finish no earlier than 2007-12-07 | S1 | 2104h | 210.4h | VAS4SMS | Wu Bin (China Mobile Communications Corporation) | wubin@chinamobile.com | Rel-8 | Michael | 22.xxx |  |  |
| 143 | 47 | Study on Requirements for seamless roaming and service continuity between mobile and WLAN networks | 132d? | 2006-12-06 A | 2007-06-07 | 10% | 118.8d? | 2006-12-06 | 2007-06-07 | 132d? | 472d | finish no earlier than 2007-06-07 | S1 | 1056h | 105.6h | SMLSWLAN | Mike Meyerstein (BT) | mike.meyerstein@bt.com | Rel-8 | Michael | 22.937 |  |  |
| 144 | 48 | Feasibility Study of Mobility between 3GPP-WLAN Interworking and 3GPP Systems | 129d? | 2007-03-20 A | 2007-09-14 | 40% | 77.4d? |  |  |  | 401d | start no earlier than 2007-03-20 | S2 | 1032h | 412.8h | SM3GWLAN | Orange | orange | Rel-8 | Maurice | 23.837 |  |  |

Notes:
- 110: Moved from FS section Feb 06. SP-33: Create new section to capture the PNM stage 2 aspects and identify any impacts to existing stage 2 specifications. S2 added as secondary responsibility
- 111: Moved from FS section Feb 06: SP-33: Create new section to capture the PNM stage 2 aspects and identify any impacts to existing stage 2 specifications.
- 114: Moved from FS section Feb 06: SP-33: Create new section to capture the PNM stage 2 aspects and identify any impacts to existing stage 2 specifications.
- 117: Moved from Rel7
- 119: WID approved SA#35
- 122: az: WID URL corrected
- 123: CT#34: WID updated. Completion 12/06 =>03/07
- 125: New WID approved SP-34. Supporting companies: Telcordia, Samsung, Qualcomm, BT, LG Electronics, Cingular, Alcatel-Lucent. No scheduled end date!
- 129: WID approved SA#35
- 133: Study approved SA#32
- 136: Formerly called "Consumer protection against spam and malware"
- 138: Approved at SP#33
- 144: Rapporteur name to be provided. Supporting companies: T-Mobile, Orange, China Mobile, Telenor, Alcatel-Lucent, Azaire Networks, Airvana

| ID | WBS | Task | Duration | Start | Finish | Complete | Remaining | Baseline start | Baseline finish | Baseline duration | Total slack | Constraint | Resources | Work | Actual work | Text4 | Text5 | Text6 | Text8 | Text3 | Text12 | Text1 |
| --- | --- | --- | --- | --- | --- | --- | --- | --- | --- | --- | --- | --- | --- | --- | --- | --- | --- | --- | --- | --- | --- | --- |
| 145 | 49 | **OAM&P Rel-8 Studies (not yet official)** | 725d? | 2005-09-02 A | 2008-06-12 | 45% | 402.1d? |  |  |  | 207d |  | S5 | 19225.6h | 7097.6h | Christian Toche | christian.toche@huawei.com | Rel-8 | Adrian |  |  |  |
| 146 | 49.1 | Study of Element Operations Systems Function (EOSF) definition | 596d? | 2005-09-02 A | 2007-12-14 | 20% | 476.8d? | 2005-09-02 | 2008-12-15 | 857d? | 336d | finish no earlier than 2007-12-14 | S5 | 4768h | 953.6h | China Mobile |  | Rel-8 |  | TR 32.819 | SP-32 |  |
| 147 | 49.2 | Study on SA5 MTOSI XML Harmonization | 418d? | 2006-05-10 A | 2007-12-14 | 90% | 41.8d? | 2006-05-10 | 2008-12-15 | 679d? | 336d | finish no earlier than 2007-12-14 | S5 | 3344h | 3009.6h | Nortel |  | Rel-8 |  | TR 32.818 | SP-32 |  |
| 148 | 49.3 | Study of Common Profile Storage (CPS) Framework of User Data for network services and management | 244d? | 2006-07-03 A | 2007-06-07 A | 100% |  | 2006-07-03 | 2007-03-15 | 184d? |  | finish no earlier than 2007-06-07 | S5 | 1952h | 1952h | T-Mobile |  | Rel-8 |  | TR 32.808 |  |  |
| 149 | 49.4 | Study of Management for LTE and SAE | 202d? | 2006-12-07 A | 2007-09-14 | 60% | 80.8d? | 2006-12-07 | 2007-06-14 | 136d? | 401d | finish no earlier than 2007-09-14 | S5 | 1616h | 969.6h | Ericsson |  | Rel-8 |  | TR 32.816 |  |  |
| 150 | 49.5 | Study of System Maintenance by Itf-N | 266d? | 2007-06-07 A | 2008-06-12 | 5% | 252.7d? |  |  |  | 207d | finish no earlier than 2008-06-12 | S5 | 2128h | 106.4h | ZTE |  | Rel-8 |  | TR 32.8xy |  |  |
| 151 | 49.6 | Study of Self-Organizing Networks (SON) related OAM interfaces for Home NodeB | 266d? | 2007-06-07 A | 2008-06-12 | 5% | 252.7d? |  |  |  | 207d | finish no earlier than 2008-06-12 | S5 | 2128h | 106.4h | Huawei |  | Rel-8 |  | TR 32.8xy |  |  |
| 152 | 50 | SI on AS-MRFC media server control protocol | 318d? | 2006-03-22 A | 2007-06-08 | 75% | 79.5d? | 2006-03-22 | 2007-06-08 | 318d? | 471d | finish no earlier than 2007-06-08 | C1 | 2544h | 1908h | Mark Syrett (Hewlett-Packard) |  | Rel-8 |  | New TR 24.880 |  | MRFC |
| 153 | 51 | FS Restoration Procedures | 180d? | 2007-03-26 A | 2007-11-30 | 10% | 162d? |  |  |  | 346d | start no earlier than 2007-03-26 | C4 | 1440h | 144h | German Blanco (Ericsson) | german.blanco@ericsson.com | Rel-8 | Kimmo | New TR 23.xyz |  | FSIMS8_RP |
| 154 | 52 | FS on 3G Home NodeB | 210d? | 2007-03-05 | 2007-12-21 |  |  |  |  |  | 331d | finish no earlier than 2007-12-21 | R4 | 1680h |  | Howard Thomas (Motorola) |  | Rel-8 | Claude |  |  | FSHNB |
| 155 | 53 | FS on MMSC | 158d? | 2007-04-26 A | 2007-12-03 | 5% | 150.1d? |  |  |  | 345d | finish no earlier than 2007-12-01 | S2 | 1264h | 63.2h |  |  | Rel-8 | Maurice | 23.8yz |  | MMSC_FS |
| 156 | 54 | FS on CS Domain Services over evolved PS access | 328d? | 2007-04-25 | 2008-07-25 |  |  |  |  |  | 176d | finish no earlier than 2008-07-25 | S2 | 2624h |  | Sabine Demel (T-Mobile International) | Sabine (dot) Demel (at) T-Mobile (dot) at | Rel-8 | Maurice | 23.8nn |  | FS_CSoPS |

Notes:
- 145: Created to encompass the Rel7 Work Tasks shifted to Rel8
- 146: Request to TSG#35 to move to Release 8
- 147: Request to TSG#35 to move to Release 8
- 148: Submit Exception Sheet for TSG#35 Approval
- 149: 12/2006 SA#34 WID approved
- 155: SID created at S2-57
- 156: SID created at S2-57
